# Commercial Construction

How a schedule from MS Project changed from version to version. A marks actual dates.

## Version 1 (saved 2025-04-25, file CommercialConstruction_lesson8.mpp)

| ID | WBS | Task | Duration | Start | Finish | Predecessors | Total float | Constraint |
| --- | --- | --- | --- | --- | --- | --- | --- | --- |
| 1 | 1 | **General Conditions** | 24.75d | 2016-08-22 | 2016-09-23 |  | 25.25d |  |
| 2 |  | Receive notice to proceed and sign contract | 3d | 2016-08-22 | 2016-08-24 |  | 116d |  |
| 3 |  | Submit bond and insurance documents | 2d | 2016-08-25 | 2016-08-26 | 2 | 116d |  |
| 4 |  | Prepare, review and submit project schedule | 2d | 2016-08-29 | 2016-08-30 | 3 | 116d |  |
| 5 |  | Obtain building permits | 4d | 2016-08-31 | 2016-09-05 | 4 | 116d |  |
| 6 |  | Submit preliminary shop drawings | 2w | 2016-09-06 | 2016-09-19 | 5 | 116d |  |
| 7 |  | Submit monthly requests for payment | 6h | 2016-09-23 | 2016-09-23 | 6 | 25.25d |  |
| 8 |  | Final General Condition | 0d | 2016-09-23 | 2016-09-23 | 7 | 122.25d |  |
| 9 | 2 | **Long Lead Procurement** | 26.25d | 2016-09-09 | 2016-10-17 |  | 13.75d |  |
| 10 |  | Submit shop drawings and order long lead items - steel | 2w | 2016-09-09 | 2016-09-23 | 7FF | 13.75d |  |
| 11 |  | Submit shop drawings and order long lead items - roofing | 2w | 2016-09-20 | 2016-10-03 | 6 | 116d |  |
| 12 |  | Detail, fabricate and deliver steel | 4w | 2016-09-20 | 2016-10-17 | 11SS | 106d |  |
| 13 |  | Long Lead Procurement check all items | 0d | 2016-10-17 | 2016-10-17 | 12 | 106d |  |
| 14 | 2 | **Mobilize on Site** | 10.25d | 2016-09-23 | 2016-10-07 |  | 11d |  |
| 15 |  | Install temporary power | 2.5d | 2016-09-23 | 2016-09-28 | 10 | 13.75d |  |
| 16 |  | Set up site office | 3d | 2016-09-28 | 2016-10-03 | 15 | 13.75d |  |
| 17 |  | Prepare site - lay down yard and temporary fencing | 2d | 2016-10-06 | 2016-10-07 | 16 | 11d |  |
| 18 |  | Finish temporay utilities | 0d | 2016-10-07 | 2016-10-07 | 17 | 112d |  |
| 19 | 3 | **Site Grading and Utilities** | 28d | 2016-10-10 | 2016-11-16 |  | 11d |  |
| 20 |  | Clear and grub site | 3d | 2016-10-10 | 2016-10-12 | 16, 17 | 11d |  |
| 21 |  | Rough grade site (cut and fill) | 1w | 2016-10-13 | 2016-10-19 | 17, 20 | 11d |  |
| 22 |  | Install exterior fire line and building fire riser | 2w | 2016-10-20 | 2016-11-02 | 21 | 11d |  |
| 23 |  | Perform final site grading | 2w | 2016-11-03 | 2016-11-16 | 22 | 11d |  |
| 24 |  | Install Utilities check | 0d | 2016-11-16 | 2016-11-16 | 23 | 11d |  |
| 25 | 4 | **Team meeting and discussion with partners** | 20.25d | 2017-01-04 | 2017-02-01 |  | 32.75d |  |
| 26 |  | Team meeting and discussion with partners 1 | 2h | 2017-01-04 | 2017-01-04 |  | 52.75d | start no earlier than 2017-01-04 |
| 27 |  | Team meeting and discussion with partners 2 | 2h | 2017-01-18 | 2017-01-18 |  | 42.75d | start no earlier than 2017-01-18 |
| 28 |  | Team meeting and discussion with partners 3 | 2h | 2017-02-01 | 2017-02-01 |  | 32.75d | start no earlier than 2017-02-01 |
| 29 | 5 | **Foundations** | 26.5d | 2016-11-17 | 2016-12-23 |  | 0d |  |
| 30 |  | Excavate foundations | 2w | 2016-11-17 | 2016-11-30 | 24 | 11d |  |
| 31 |  | Rough-in electric and plumbing in elevator | 4d | 2016-11-24 | 2016-11-29 | 30SS | 67d | start no earlier than 2016-11-24 |
| 32 |  | Pour column piers and foundations | 5d | 2016-11-30 | 2016-12-06 | 31 | 67d |  |
| 33 |  | Pour concrete elevator walls | 3d | 2016-12-07 | 2016-12-09 | 31, 32 | 67d |  |
| 34 |  | Cure elevator wall concrete | 1d | 2016-12-09 | 2016-12-09 | 30, 33FF | 5d |  |
| 35 |  | Strip wall forms | 3d | 2016-12-19 | 2016-12-21 | 34FS+5d | 0d |  |
| 36 |  | Prepare and pour concrete floor in elevator pit | 12h | 2016-12-22 | 2016-12-23 | 35 | 0d |  |
| 37 |  | Foundation inspection | 0d | 2016-12-23 | 2016-12-23 | 36 | 0d |  |
| 38 | 6 | **Building Finishes** | 52.5d | 2016-12-23 | 2017-03-10 |  | 0d |  |
| 39 |  | Install millwork and wood trim | 3w | 2016-12-23 | 2017-01-18 | 37SS | 5d |  |
| 40 |  | Paint walls and woodwork | 1mo | 2017-01-18 | 2017-02-22 | 39 | 4d |  |
| 41 |  | Install conduit at ceiling plenum space | 2.5w | 2017-02-22 | 2017-03-10 | 40 | 5d |  |
| 42 |  | Install duct in ceiling plenum space | 3w | 2016-12-23 | 2017-01-18 | 37 | 0d |  |
| 43 |  | Install ceiling grid | 1w | 2017-01-18 | 2017-01-27 | 42 | 0d |  |
| 44 |  | Install ceiling tile | 2w | 2017-01-27 | 2017-02-15 | 43 | 0d |  |
| 45 |  | Hang wallpaper | 2w | 2017-02-15 | 2017-03-03 | 44 | 0d |  |
| 46 |  | Building Finishes inspection | 0d | 2017-03-03 | 2017-03-03 | 45 | 0d |  |
| 47 | 7 | **Final Clean-up and Occupancy** | 7d | 2017-03-03 | 2017-03-14 |  | 0d |  |
| 48 |  | Install hard tile flooring in common areas | 1w | 2017-03-03 | 2017-03-10 | 46 | 0d |  |
| 49 |  | Remove debris from building and do final clean-up | 1d | 2017-03-10 | 2017-03-13 | 48 | 0d |  |
| 50 |  | Substantial completion date | 1d | 2017-03-13 | 2017-03-14 | 49 | 3.5d |  |
| 51 | 8 | **Complete Final Inspections** | 2.69d | 2017-03-13 | 2017-03-16 |  | 0d |  |
| 52 |  | Complete elevator inspection and certification | 0.5d | 2017-03-13 | 2017-03-13 | 49 | 0d |  |
| 53 |  | Perform architect's inspection | 2d | 2017-03-14 | 2017-03-15 | 52 | 0d |  |
| 54 |  | Perform Fire Marshal's inspection | 90min | 2017-03-16 | 2017-03-16 | 53 | 0.81d |  |
| 55 |  | Issue final completion documents including warranties | 1d | 2017-03-16 | 2017-03-16 | 53 | 0d | start no earlier than 2017-01-09 |
| 56 |  | Issue final request for payment | 1d | 2017-03-17 | 2017-03-17 | 54, 55 | 0d |  |

## Version 2 (saved 2025-04-25, file CommercialConstruction_lesson9.mpp)

Last finish stays 2017-03-17. Complete tasks 0 → 9.

Changed:

| ID | Task | Start | Finish | Complete | Total float |
| --- | --- | --- | --- | --- | --- |
| 1 | **General Conditions** | 2016-08-22 A |  | 0% → 50% |  |
| 2 | Receive notice to proceed and sign contract | 2016-08-22 A | 2016-08-24 A | 0% → 100% | 116d → none |
| 3 | Submit bond and insurance documents | 2016-08-25 A | 2016-08-26 A | 0% → 100% | 116d → none |
| 4 | Prepare, review and submit project schedule | 2016-08-29 A | 2016-08-30 A | 0% → 100% | 116d → none |
| 5 | Obtain building permits | 2016-08-31 A | 2016-09-05 A | 0% → 100% | 116d → none |
| 9 | **Long Lead Procurement** | 2016-09-09 A |  | 0% → 25% |  |
| 10 | Submit shop drawings and order long lead items - steel | 2016-09-09 A | 2016-09-23 A | 0% → 100% | 13.75d → none |
| 14 | **Mobilize on Site** | 2016-09-23 A |  | 0% → 8% |  |
| 15 | Install temporary power | 2016-09-23 A |  | 0% → 25% |  |
| 25 | **Team meeting and discussion with partners** | 2017-01-04 A | 2017-02-01 A | 0% → 100% | 32.75d → none |
| 26 | Team meeting and discussion with partners 1 | 2017-01-04 A | 2017-01-04 A | 0% → 100% | 52.75d → none |
| 27 | Team meeting and discussion with partners 2 | 2017-01-18 A | 2017-01-18 A | 0% → 100% | 42.75d → none |
| 28 | Team meeting and discussion with partners 3 | 2017-02-01 A | 2017-02-01 A | 0% → 100% | 32.75d → none |
| 29 | **Foundations** | 2016-11-17 A |  | 0% → 36% |  |
| 30 | Excavate foundations | 2016-11-17 A | 2016-11-30 A | 0% → 100% | 11d → none |
| 38 | **Building Finishes** | 2016-12-23 A |  | 0% → 10% |  |
| 39 | Install millwork and wood trim | 2016-12-23 A |  | 0% → 50% |  |
| 43 | Install ceiling grid | 2017-01-18 A |  | 0% → 25% |  |

## Version 3 (saved 2025-04-25, file CommercialConstruction_lesson7.mpp)

Last finish 2017-03-17 → 2017-05-26 (+70d). Complete tasks 9 → 0.

Changed:

| ID | Task | Start | Finish | Duration | Complete | Total float | Predecessors | Other |
| --- | --- | --- | --- | --- | --- | --- | --- | --- |
| 1 | **General Conditions** | 2016-08-22 A → 2016-08-22 |  |  | 50% → 0% | 25.25d → 34.88d |  | baseline start 2016-08-22 → none; baseline finish 2016-09-23 → none |
| 2 | Receive notice to proceed and sign contract | 2016-08-22 A → 2016-08-22 | 2016-08-24 A → 2016-08-24 |  | 100% → 0% | none → 164.62d |  | baseline start 2016-08-22 → none; baseline finish 2016-08-24 → none |
| 3 | Submit bond and insurance documents | 2016-08-25 A → 2016-08-25 | 2016-08-26 A → 2016-08-26 |  | 100% → 0% | none → 164.62d |  | baseline start 2016-08-25 → none; baseline finish 2016-08-26 → none |
| 4 | Prepare and submit project schedule | 2016-08-29 A → 2016-08-29 | 2016-08-30 A → 2016-08-30 |  | 100% → 0% | none → 164.62d |  | was named Prepare, review and submit project schedule; baseline start 2016-08-29 → none; baseline finish 2016-08-30 → none |
| 5 | Obtain building permits | 2016-08-31 A → 2016-08-31 | 2016-09-05 A → 2016-09-05 |  | 100% → 0% | none → 164.62d |  | baseline start 2016-08-31 → none; baseline finish 2016-09-05 → none |
| 6 | Submit preliminary shop drawings |  |  |  |  | 116d → 164.62d |  | baseline start 2016-09-06 → none; baseline finish 2016-09-19 → none |
| 7 | Submit monthly requests for payment |  |  |  |  | 25.25d → 34.88d |  | baseline start 2016-09-23 → none; baseline finish 2016-09-23 → none |
| 8 | Final General Condition |  |  |  |  | 122.25d → 170.88d |  | baseline start 2016-09-23 → none; baseline finish 2016-09-23 → none |
| 9 | **Long Lead Procurement** | 2016-09-09 A → 2016-09-09 |  |  | 25% → 0% | 13.75d → 120.88d |  | baseline start 2016-09-09 → none; baseline finish 2016-10-17 → none |
| 10 | Submit shop drawings and order long lead items - steel | 2016-09-09 A → 2016-09-09 | 2016-09-23 A → 2016-09-23 |  | 100% → 0% | none → 120.88d |  | baseline start 2016-09-09 → none; baseline finish 2016-09-23 → none |
| 11 | Submit shop drawings and order long lead items - roofing |  |  |  |  | 116d → 164.62d |  | baseline start 2016-09-20 → none; baseline finish 2016-10-03 → none |
| 12 | Detail, fabricate and deliver steel |  |  |  |  | 106d → 154.62d |  | baseline start 2016-09-20 → none; baseline finish 2016-10-17 → none |
| 13 | Long Lead Procurement check all items |  |  |  |  | 106d → 154.62d |  | baseline start 2016-10-17 → none; baseline finish 2016-10-17 → none |
| 14 | **Mobilize on Site** | 2016-09-23 A → 2016-09-23 |  |  | 8% → 0% | 11d → 118.12d |  | baseline start 2016-09-23 → none; baseline finish 2016-10-07 → none |
| 15 | Install temporary power | 2016-09-23 A → 2016-09-23 |  |  | 25% → 0% | 13.75d → 120.88d |  | baseline start 2016-09-23 → none; baseline finish 2016-09-28 → none |
| 16 | Set up site office |  |  |  |  | 13.75d → 120.88d |  | baseline start 2016-09-28 → none; baseline finish 2016-10-03 → none |
| 17 | Prepare site - lay down yard and temporary fencing |  |  |  |  | 11d → 118.12d |  | baseline start 2016-10-06 → none; baseline finish 2016-10-07 → none |
| 18 | Finish temporay utilities |  |  |  |  | 112d → 160.62d |  | baseline start 2016-10-07 → none; baseline finish 2016-10-07 → none |
| 19 | **Site Grading and Utilities** |  |  |  |  | 11d → 118.12d |  | baseline start 2016-10-10 → none; baseline finish 2016-11-16 → none |
| 20 | Clear and grub site |  |  |  |  | 11d → 118.12d |  | baseline start 2016-10-10 → none; baseline finish 2016-10-12 → none |
| 21 | Rough grade site (cut and fill) |  |  |  |  | 11d → 118.12d |  | baseline start 2016-10-13 → none; baseline finish 2016-10-19 → none |
| 22 | Install exterior fire line and building fire riser |  |  |  |  | 11d → 118.12d |  | baseline start 2016-10-20 → none; baseline finish 2016-11-02 → none |
| 23 | Perform final site grading |  |  |  |  | 11d → 118.12d |  | baseline start 2016-11-03 → none; baseline finish 2016-11-16 → none |
| 24 | Install Utilities check |  |  |  |  | 11d → 118.12d |  | baseline start 2016-11-16 → none; baseline finish 2016-11-16 → none |
| 25 | **Team meeting and discussion with partners** | 2017-01-04 A → 2017-01-04 | 2017-02-01 A → 2017-02-01 |  | 100% → 0% | none → 81.38d |  | baseline start 2017-01-04 → none; baseline finish 2017-02-01 → none |
| 26 | Team meeting and discussion with partners 1 | 2017-01-04 A → 2017-01-04 | 2017-01-04 A → 2017-01-04 |  | 100% → 0% | none → 101.38d |  | baseline start 2017-01-04 → none; baseline finish 2017-01-04 → none |
| 27 | Team meeting and discussion with partners 2 | 2017-01-18 A → 2017-01-18 | 2017-01-18 A → 2017-01-18 |  | 100% → 0% | none → 91.38d |  | baseline start 2017-01-18 → none; baseline finish 2017-01-18 → none |
| 28 | Team meeting and discussion with partners 3 | 2017-02-01 A → 2017-02-01 | 2017-02-01 A → 2017-02-01 |  | 100% → 0% | none → 81.38d |  | baseline start 2017-02-01 → none; baseline finish 2017-02-01 → none |
| 29 | **Foundations** | 2016-11-17 A → 2016-11-17 | 2016-12-23 → 2016-12-14 (-9d) | 26.5d → 19.5d | 36% → 0% | 0d → 113.12d |  | baseline start 2016-11-17 → none; baseline finish 2016-12-16 → none |
| 30 | Excavate foundations | 2016-11-17 A → 2016-11-17 | 2016-11-30 A → 2016-11-30 |  | 100% → 0% | none → 118.12d |  | baseline start 2016-11-17 → none; baseline finish 2016-11-30 → none |
| 31 | Rough-in electric and plumbing in elevator | 2016-11-24 → 2016-11-17 (-7d) | 2016-11-29 → 2016-11-22 (-7d) |  |  | 67d → 122.12d |  | constraint start no earlier than 2016-11-24 → none; baseline start 2016-11-17 → none; baseline finish 2016-11-22 → none |
| 32 | Pour column piers and foundations | 2016-11-30 → 2016-11-23 (-7d) | 2016-12-06 → 2016-11-29 (-7d) |  |  | 67d → 122.12d |  | baseline start 2016-11-23 → none; baseline finish 2016-11-29 → none |
| 33 | Pour concrete elevator walls | 2016-12-07 → 2016-11-30 (-7d) | 2016-12-09 → 2016-12-01 (-8d) | 3d → 1.5d |  | 67d → 122.12d |  | baseline start 2016-11-30 → none; baseline finish 2016-12-02 → none |
| 34 | Cure elevator wall concrete | 2016-12-09 → 2016-12-01 (-8d) | 2016-12-09 → 2016-12-01 (-8d) |  |  | 5d → 118.12d |  | baseline start 2016-12-02 → none; baseline finish 2016-12-02 → none |
| 35 | Strip wall forms | 2016-12-19 → 2016-12-09 (-10d) | 2016-12-21 → 2016-12-12 (-9d) | 3d → 2d |  | 0d → 113.12d |  | baseline start 2016-12-12 → none; baseline finish 2016-12-14 → none |
| 36 | Prepare and pour concrete floor in elevator pit | 2016-12-22 → 2016-12-13 (-9d) | 2016-12-23 → 2016-12-14 (-9d) |  |  | 0d → 113.12d |  | baseline start 2016-12-15 → none; baseline finish 2016-12-16 → none |
| 37 | Foundation inspection | 2016-12-23 → 2016-12-14 (-9d) | 2016-12-23 → 2016-12-14 (-9d) |  |  | 0d → 113.12d |  | baseline start 2016-12-16 → none; baseline finish 2016-12-16 → none |
| 38 | **Building Finishes** | 2016-12-23 A → 2016-12-14 (-9d) | 2017-03-10 → 2017-05-16 (+67d) | 52.5d → 105d | 10% → 0% |  |  | baseline start 2016-12-16 → none; baseline finish 2017-05-19 → none |
| 39 | Install millwork and wood trim | 2016-12-23 A → 2016-12-14 (-9d) | 2017-01-18 → 2017-01-09 (-9d) |  | 50% → 0% | 5d → 1d |  | baseline start 2016-12-16 → none; baseline finish 2017-01-11 → none |
| 40 | Paint walls and woodwork | 2017-01-18 → 2017-01-10 (-8d) | 2017-02-22 → 2017-02-10 (-12d) |  |  | 4d → 0.5d |  | baseline start 2017-01-11 → none; baseline finish 2017-02-15 → none |
| 41 | Install conduit at ceiling plenum space | 2017-02-22 → 2017-02-13 (-9d) | 2017-03-10 → 2017-03-01 (-9d) |  |  | 5d → 0.5d |  | baseline start 2017-02-15 → none; baseline finish 2017-03-03 → none |
| 42 | Install duct in ceiling plenum space | 2016-12-23 → 2017-03-01 (+68d) | 2017-01-18 → 2017-03-21 (+62d) |  |  |  | 37 → 41FS-4h | baseline start 2017-03-03 → none; baseline finish 2017-03-24 → none |
| 43 | Install ceiling grid | 2017-01-18 A → 2017-03-22 (+63d) | 2017-01-27 → 2017-04-10 (+73d) | 1w → 2w | 25% → 0% |  |  | resources Drywall Contractor [200%] → Drywall Contractor; baseline start 2017-03-24 → none; baseline finish 2017-04-12 → none |
| 44 | Install ceiling tile | 2017-01-27 → 2017-04-10 (+73d) | 2017-02-15 → 2017-04-27 (+71d) |  |  |  |  | baseline start 2017-04-13 → none; baseline finish 2017-05-03 → none |
| 45 | Hang wallpaper | 2017-02-15 → 2017-04-27 (+71d) | 2017-03-03 → 2017-05-16 (+74d) |  |  |  |  | baseline start 2017-05-03 → none; baseline finish 2017-05-19 → none |
| 46 | Building Finishes inspection | 2017-03-03 → 2017-05-16 (+74d) | 2017-03-03 → 2017-05-16 (+74d) |  |  |  |  | baseline start 2017-05-19 → none; baseline finish 2017-05-19 → none |
| 47 | **Final Clean-up and Occupancy** | 2017-03-03 → 2017-05-16 (+74d) | 2017-03-14 → 2017-05-24 (+71d) | 7d → 6d |  |  |  | baseline start 2017-05-19 → none; baseline finish 2017-05-29 → none |
| 48 | Install hard tile flooring in common areas | 2017-03-03 → 2017-05-16 (+74d) | 2017-03-10 → 2017-05-22 (+73d) |  |  |  |  | baseline start 2017-05-19 → none; baseline finish 2017-05-25 → none |
| 49 | Remove debris from building and do final clean-up | 2017-03-10 → 2017-05-22 (+73d) | 2017-03-13 → 2017-05-23 (+71d) |  |  |  |  | baseline start 2017-05-25 → none; baseline finish 2017-05-26 → none |
| 50 | Substantial completion date | 2017-03-13 → 2017-05-23 (+71d) | 2017-03-14 → 2017-05-24 (+71d) |  |  | 3.5d → 2.12d |  | baseline start 2017-05-26 → none; baseline finish 2017-05-29 → none |
| 51 | **Complete Final Inspections** | 2017-03-13 → 2017-05-23 (+71d) | 2017-03-16 → 2017-05-24 (+69d) | 2.69d → 1.31d |  |  |  | baseline start 2017-05-26 → none; baseline finish 2017-05-29 → none |
| 52 | Complete elevator inspection and certification | 2017-03-13 → 2017-05-23 (+71d) | 2017-03-13 → 2017-05-23 (+71d) |  |  |  |  | baseline start 2017-05-26 → none; baseline finish 2017-05-26 → none |
| 53 | Perform architect's inspection | 2017-03-14 → 2017-05-24 (+71d) | 2017-03-15 → 2017-05-24 (+70d) | 2d → 5h |  |  |  | baseline start 2017-05-26 → none; baseline finish 2017-05-29 → none |
| 54 | Perform Fire Marshal's inspection | 2017-03-16 → 2017-05-24 (+69d) | 2017-03-16 → 2017-05-24 (+69d) |  |  |  |  | baseline start 2017-05-29 → none; baseline finish 2017-05-29 → none |
| 55 | Issue final completion documents including warranties | 2017-03-16 → 2017-05-24 (+69d) | 2017-03-16 → 2017-05-25 (+70d) |  |  |  |  | baseline start 2017-05-29 → none; baseline finish 2017-05-30 → none |
| 56 | Issue final request for payment | 2017-03-17 → 2017-05-25 (+69d) | 2017-03-17 → 2017-05-26 (+70d) |  |  |  |  | baseline start 2017-05-30 → none; baseline finish 2017-05-31 → none |

## Version 4 (saved 2025-04-25, file CommercialConstruction_lesson2.mpp)

Last finish 2017-05-26 → 2017-05-17 (-9d).

Changed:

| ID | Task | Start | Finish | Duration | Total float | Predecessors | Other |
| --- | --- | --- | --- | --- | --- | --- | --- |
| 1 | **General Conditions** | 2016-08-22 → 2016-08-15 (-7d) | 2016-09-23 → 2016-09-13 (-10d) | 24.75d → 21.75d | 34.88d → 166.62d |  |  |
| 2 | Receive notice to proceed and sign contract | 2016-08-22 → 2016-08-15 (-7d) | 2016-08-24 → 2016-08-17 (-7d) |  | 164.62d → 166.62d |  | resources G.C. General Management → none |
| 3 | Submit bond and insurance documents | 2016-08-25 → 2016-08-18 (-7d) | 2016-08-26 → 2016-08-19 (-7d) |  | 164.62d → 166.62d |  | resources G.C. Project Management; G.C. General Management [25%] → none |
| 4 | Prepare and submit project schedule | 2016-08-29 → 2016-08-22 (-7d) | 2016-08-30 → 2016-08-23 (-7d) |  | 164.62d → 166.62d |  | resources G.C. Project Management [25%]; G.C Scheduler → none |
| 5 | Obtain building permits | 2016-08-31 → 2016-08-24 (-7d) | 2016-09-05 → 2016-08-29 (-7d) |  | 164.62d → 166.62d |  | resources G.C. Project Management [50%]; G.C Procurement [50%] → none |
| 6 | Submit preliminary shop drawings | 2016-09-06 → 2016-08-30 (-7d) | 2016-09-19 → 2016-09-12 (-7d) |  | 164.62d → 166.62d |  | resources G.C. Project Management [50%]; G.C Procurement [50%] → none |
| 7 | Submit monthly requests for payment | 2016-09-23 → 2016-09-13 (-10d) | 2016-09-23 → 2016-09-13 (-10d) |  | 34.88d → 175.88d |  |  |
| 8 | Final General Condition | 2016-09-23 → 2016-09-13 (-10d) | 2016-09-23 → 2016-09-13 (-10d) |  | 170.88d → 175.88d |  |  |
| 9 | **Long Lead Procurement** | 2016-09-09 → 2016-08-30 (-10d) | 2016-10-17 → 2016-10-10 (-7d) | 26.25d → 29.25d | 120.88d → 140.38d |  |  |
| 10 | Submit shop drawings and order long lead items - steel | 2016-09-09 → 2016-08-30 (-10d) | 2016-09-23 → 2016-09-13 (-10d) |  | 120.88d → 140.38d |  | resources Steel Erection Contractor Management → none |
| 11 | Submit shop drawings and order long lead items - roofing | 2016-09-20 → 2016-09-13 (-7d) | 2016-10-03 → 2016-09-26 (-7d) |  | 164.62d → 166.62d |  | resources Roofing Contractor Management → none |
| 12 | Detail, fabricate and deliver steel | 2016-09-20 → 2016-09-13 (-7d) | 2016-10-17 → 2016-10-10 (-7d) |  | 154.62d → 156.62d |  | resources Steel Erection Contractor Management [50%]; Steel Erection Contractor [50%] → none |
| 13 | Long Lead Procurement check all items | 2016-10-17 → 2016-10-10 (-7d) | 2016-10-17 → 2016-10-10 (-7d) |  | 154.62d → 156.62d |  |  |
| 14 | **Mobilize on Site** | 2016-09-23 → 2016-09-13 (-10d) | 2016-10-07 → 2016-09-23 (-14d) | 10.25d → 7.5d | 118.12d → 140.38d |  |  |
| 15 | Install temporary power | 2016-09-23 → 2016-09-13 (-10d) | 2016-09-28 → 2016-09-16 (-12d) |  | 120.88d → 140.38d |  | resources Electric Contractor → none |
| 16 | Set up site office | 2016-09-28 → 2016-09-16 (-12d) | 2016-10-03 → 2016-09-21 (-12d) |  | 120.88d → 140.38d |  | resources G.C. Superintendent; G.C. Labor Crew [10%] → none |
| 17 | Prepare site - lay down yard and temporary fencing | 2016-10-06 → 2016-09-21 (-15d) | 2016-10-07 → 2016-09-23 (-14d) |  | 118.12d → 140.38d |  | resources Site Grading Contractor; G.C. Labor Crew [10%] → none |
| 18 | Finish temporay utilities | 2016-10-07 → 2016-09-23 (-14d) | 2016-10-07 → 2016-09-23 (-14d) |  | 160.62d → 168.38d |  |  |
| 19 | **Site Grading and Utilities** | 2016-10-10 → 2016-09-23 (-17d) | 2016-11-16 → 2016-11-02 (-14d) |  | 118.12d → 140.38d |  |  |
| 20 | Clear and grub site | 2016-10-10 → 2016-09-23 (-17d) | 2016-10-12 → 2016-09-28 (-14d) |  | 118.12d → 140.38d |  | resources Site Grading Contractor → none |
| 21 | Rough grade site (cut and fill) | 2016-10-13 → 2016-09-28 (-15d) | 2016-10-19 → 2016-10-05 (-14d) |  | 118.12d → 140.38d |  | resources Site Grading Contractor → none |
| 22 | Install exterior fire line and building fire riser | 2016-10-20 → 2016-10-05 (-15d) | 2016-11-02 → 2016-10-19 (-14d) |  | 118.12d → 140.38d |  | resources Plumbing Contractor → none |
| 23 | Perform final site grading | 2016-11-03 → 2016-10-19 (-15d) | 2016-11-16 → 2016-11-02 (-14d) |  | 118.12d → 140.38d |  | resources Site Grading Contractor → none |
| 24 | Install Utilities check | 2016-11-16 → 2016-11-02 (-14d) | 2016-11-16 → 2016-11-02 (-14d) |  | 118.12d → 140.38d |  |  |
| 29 | **Foundations** | 2016-11-17 → 2016-11-30 (+13d) | 2016-12-14 → 2016-12-27 (+13d) |  | 113.12d → 0d |  |  |
| 30 | Excavate foundations | 2016-11-17 → 2016-11-30 (+13d) | 2016-11-30 → 2016-12-13 (+13d) |  | 118.12d → 0d | 24 → none | constraint none → must finish on 2016-12-13; resources G.C. Labor Crew; Site Grading Contractor [50%] → none |
| 31 | Rough-in electric and plumbing in elevator | 2016-11-17 → 2016-11-30 (+13d) | 2016-11-22 → 2016-12-05 (+13d) |  | 122.12d → 110.12d |  | resources Plumbing Contractor; Electric Contractor → none |
| 32 | Pour column piers and foundations | 2016-11-23 → 2016-12-06 (+13d) | 2016-11-29 → 2016-12-12 (+13d) |  | 122.12d → 110.12d |  | resources G.C. Concrete Crew [150%] → none |
| 33 | Pour concrete elevator walls | 2016-11-30 → 2016-12-13 (+13d) | 2016-12-01 → 2016-12-14 (+13d) |  | 122.12d → 110.12d |  | resources G.C. Concrete Crew; Concrete [1 ton] → none |
| 34 | Cure elevator wall concrete | 2016-12-01 → 2016-12-14 (+13d) | 2016-12-01 → 2016-12-14 (+13d) |  | 118.12d → 106.12d |  | resources G.C. Labor Crew [10%] → none |
| 35 | Strip wall forms | 2016-12-09 → 2016-12-22 (+13d) | 2016-12-12 → 2016-12-23 (+11d) |  | 113.12d → 101.12d |  | resources G.C. Labor Crew [10%] → none |
| 36 | Prepare and pour concrete floor in elevator pit | 2016-12-13 → 2016-12-26 (+13d) | 2016-12-14 → 2016-12-27 (+13d) |  | 113.12d → 101.12d |  | resources G.C. Concrete Crew → none |
| 37 | Foundation inspection | 2016-12-14 → 2016-12-27 (+13d) | 2016-12-14 → 2016-12-27 (+13d) |  | 113.12d → 101.12d |  |  |
| 38 | **Building Finishes** | 2016-12-14 → 2016-12-27 (+13d) | 2017-05-16 → 2017-05-04 (-12d) | 105d → 92d |  |  |  |
| 39 | Install millwork and wood trim | 2016-12-14 → 2016-12-27 (+13d) | 2017-01-09 → 2017-01-17 (+8d) |  | 1d → 0.5d |  | resources G.C. Finish Carpenter Crew → none |
| 40 | Paint walls and woodwork | 2017-01-10 → 2017-01-17 (+7d) | 2017-02-10 → 2017-02-14 (+4d) |  |  |  | resources Painting Contractor; Painting Material [1 liter] → none |
| 41 | Install conduit at ceiling plenum space | 2017-02-13 → 2017-02-14 (+1d) | 2017-03-01 → 2017-03-02 (+1d) |  |  |  | resources Electric Contractor → none |
| 42 | Install duct in ceiling plenum space | 2017-03-01 → 2017-03-02 (+1d) | 2017-03-21 → 2017-03-23 (+2d) |  |  |  | resources HVAC Contractor → none |
| 43 | Install ceiling grid | 2017-03-22 → 2017-03-23 (+1d) | 2017-04-10 → 2017-04-06 (-4d) |  |  |  | resources Drywall Contractor → none |
| 44 | Install ceiling tile | 2017-04-10 → 2017-04-06 (-4d) | 2017-04-27 → 2017-04-20 (-7d) |  |  |  | resources Drywall Contractor → none |
| 45 | Hang wallpaper | 2017-04-27 → 2017-04-20 (-7d) | 2017-05-16 → 2017-05-04 (-12d) |  |  |  | resources Painting Contractor → none |
| 46 | Building Finishes inspection | 2017-05-16 → 2017-05-04 (-12d) | 2017-05-16 → 2017-05-04 (-12d) |  |  |  |  |
| 47 | **Final Clean-up and Occupancy** | 2017-05-16 → 2017-05-04 (-12d) | 2017-05-24 → 2017-05-15 (-9d) | 6d → 7d |  |  |  |
| 48 | Install hard tile flooring in common areas | 2017-05-16 → 2017-05-04 (-12d) | 2017-05-22 → 2017-05-11 (-11d) |  |  |  | resources Tile Contractor → none |
| 49 | Remove debris from building and do final clean-up | 2017-05-22 → 2017-05-11 (-11d) | 2017-05-23 → 2017-05-12 (-11d) |  |  |  | resources Tile Contractor [50%] → none |
| 50 | Substantial completion date | 2017-05-23 → 2017-05-12 (-11d) | 2017-05-24 → 2017-05-15 (-9d) |  |  |  | resources G.C. Superintendent → none |
| 51 | **Complete Final Inspections** | 2017-05-23 → 2017-05-12 (-11d) | 2017-05-24 → 2017-05-15 (-9d) |  |  |  |  |
| 52 | Complete elevator inspection and certification | 2017-05-23 → 2017-05-12 (-11d) | 2017-05-23 → 2017-05-12 (-11d) |  |  |  | resources Elevator Contractor → none |
| 53 | Perform architect's inspection | 2017-05-24 → 2017-05-15 (-9d) | 2017-05-24 → 2017-05-15 (-9d) |  |  |  | resources G.C. Superintendent [50%]; G.C. Project Management [50%] → none |
| 54 | Perform Fire Marshal's inspection | 2017-05-24 → 2017-05-15 (-9d) | 2017-05-24 → 2017-05-15 (-9d) |  |  |  | resources G.C. Superintendent [50%]; G.C. Project Management [50%] → none |
| 55 | Issue final completion documents including warranties | 2017-05-24 → 2017-05-15 (-9d) | 2017-05-25 → 2017-05-16 (-9d) |  |  |  | resources G.C. Project Management → none |
| 56 | Issue final request for payment | 2017-05-25 → 2017-05-16 (-9d) | 2017-05-26 → 2017-05-17 (-9d) |  |  |  | resources G.C. Project Management [33%]; G.C Accounting [33%]; G.C. General Management [33%] → none |
